# Microsoft Project 2000 Deployment Template

Schedule from MS Project, 2000-01-03 to 2000-05-17.
Microsoft Corporation

## Calendars

- Standard: Mon-Fri 08:00-12:00, 13:00-17:00; Sat-Sun off.

## Schedule

| ID | WBS | Task | Type | Duration | Start | Finish | Predecessors | Baseline start | Baseline finish | Baseline duration | Total slack |
| --- | --- | --- | --- | --- | --- | --- | --- | --- | --- | --- | --- |
| 1 | 1 | **Deploying Microsoft Project 2000 and Project Central in the Enterprise** |  | 97.75d? | 2000-01-03 | 2000-05-17 |  | 2000-01-03 | 2000-05-17 | 97.75d? | 0d |
| 2 | 1.1 | **Vision/Scope** |  | 5.5d | 2000-01-03 | 2000-01-10 |  | 2000-01-03 | 2000-01-10 | 5.5d | 0d |
| 3 | 1.1.1 | Evaluate Microsoft Project 2000 features |  | 2d | 2000-01-03 | 2000-01-04 |  | 2000-01-03 | 2000-01-04 | 2d | 0d |
| 4 | 1.1.2 | Evaluate corporate objectives for project management |  | 2d | 2000-01-05 | 2000-01-06 | 3 | 2000-01-05 | 2000-01-06 | 2d | 0d |
| 5 | 1.1.3 | Formulate preliminary cost/benefit analysis |  | 4h | 2000-01-07 | 2000-01-07 | 4 | 2000-01-07 | 2000-01-07 | 4h | 0d |
| 6 | 1.1.4 | Determine project scope (lab, pilot, international/regional deployment, coexistence strategies, etc.) |  | 4h | 2000-01-07 | 2000-01-07 | 5 | 2000-01-07 | 2000-01-07 | 4h | 0d |
| 7 | 1.1.5 | Determine major milestones |  | 2h | 2000-01-10 | 2000-01-10 | 6 | 2000-01-10 | 2000-01-10 | 2h | 0d |
| 8 | 1.1.6 | Secure executive sponsorship and funding |  | 2h | 2000-01-10 | 2000-01-10 | 7 | 2000-01-10 | 2000-01-10 | 2h | 0d |
| 9 | 1.1.7 | Vision/scope complete | milestone | 0d | 2000-01-10 | 2000-01-10 | 8 | 2000-01-10 | 2000-01-10 | 0d | 0d |
| 10 | 1.2 | **Planning** |  | 36.75d? | 2000-01-03 | 2000-02-22 |  | 2000-01-03 | 2000-02-22 | 36.75d? | 5.5d |
| 11 | 1.2.1 | **Assemble Project Teams, Define Roles** |  | 2d | 2000-01-10 | 2000-01-12 |  | 2000-01-10 | 2000-01-12 | 2d | 0d |
| 12 | 1.2.1.1 | Project manager |  | 1d | 2000-01-10 | 2000-01-11 | 9 | 2000-01-10 | 2000-01-11 | 1d | 0d |
| 13 | 1.2.1.2 | Infrastructure/network administrator |  | 1d | 2000-01-10 | 2000-01-11 | 9 | 2000-01-10 | 2000-01-11 | 1d | 0d |
| 14 | 1.2.1.3 | Deployment administrator |  | 1d | 2000-01-10 | 2000-01-11 | 9 | 2000-01-10 | 2000-01-11 | 1d | 0d |
| 15 | 1.2.1.4 | Desktop administrator |  | 1d | 2000-01-10 | 2000-01-11 | 9 | 2000-01-10 | 2000-01-11 | 1d | 0d |
| 16 | 1.2.1.5 | Intranet/internet administrator |  | 1d | 2000-01-10 | 2000-01-11 | 9 | 2000-01-10 | 2000-01-11 | 1d | 0d |
| 17 | 1.2.1.6 | Database server administrator |  | 1d | 2000-01-10 | 2000-01-11 | 9 | 2000-01-10 | 2000-01-11 | 1d | 0d |
| 18 | 1.2.1.7 | Browser administrator |  | 1d | 2000-01-10 | 2000-01-11 | 9 | 2000-01-10 | 2000-01-11 | 1d | 0d |
| 19 | 1.2.1.8 | Messaging administrator |  | 1d | 2000-01-10 | 2000-01-11 | 9 | 2000-01-10 | 2000-01-11 | 1d | 0d |
| 20 | 1.2.1.9 | Testing/quality assurance team |  | 1d | 2000-01-10 | 2000-01-11 | 9 | 2000-01-10 | 2000-01-11 | 1d | 0d |
| 21 | 1.2.1.10 | User education, training, communication |  | 1d | 2000-01-10 | 2000-01-11 | 9 | 2000-01-10 | 2000-01-11 | 1d | 0d |
| 22 | 1.2.1.11 | Establish subteam roles and responsibilities (infrastructure, security, hosting, etc.) |  | 1d | 2000-01-11 | 2000-01-12 | 21, 12, 13, 14, 15, 16, 17, 18, 19, 20 | 2000-01-11 | 2000-01-12 | 1d | 0d |
| 23 | 1.2.1.12 | Assemble project teams, define roles complete | milestone | 0d | 2000-01-12 | 2000-01-12 | 22 | 2000-01-12 | 2000-01-12 | 0d | 0d |
| 24 | 1.2.2 | **Review/Detail Current Computing Environment** |  | 6d | 2000-01-12 | 2000-01-20 |  | 2000-01-12 | 2000-01-20 | 6d | 0d |
| 25 | 1.2.2.1 | Review/detail Microsoft Project 2000 requirements |  | 1d | 2000-01-12 | 2000-01-13 | 23 | 2000-01-12 | 2000-01-13 | 1d | 0d |
| 26 | 1.2.2.2 | Review/detail technology Architecture |  | 1d | 2000-01-13 | 2000-01-14 | 25 | 2000-01-13 | 2000-01-14 | 1d | 0d |
| 27 | 1.2.2.3 | Review/detail server hardware and software inventory |  | 1d | 2000-01-14 | 2000-01-17 | 26 | 2000-01-14 | 2000-01-17 | 1d | 0d |
| 28 | 1.2.2.4 | Review/detail client hardware and software inventory |  | 1d | 2000-01-17 | 2000-01-18 | 27 | 2000-01-17 | 2000-01-18 | 1d | 0d |
| 29 | 1.2.2.5 | Review/detail current administrative/service delivery model |  | 1d | 2000-01-18 | 2000-01-19 | 28 | 2000-01-18 | 2000-01-19 | 1d | 0d |
| 30 | 1.2.2.6 | Document current computing environment |  | 1d | 2000-01-19 | 2000-01-20 | 29 | 2000-01-19 | 2000-01-20 | 1d | 0d |
| 31 | 1.2.2.7 | Detail current computing environment complete | milestone | 0d | 2000-01-20 | 2000-01-20 | 30 | 2000-01-20 | 2000-01-20 | 0d | 0d |

Notes:
- 1: This Microsoft Project 2000 Deployment Template is designed to facilitate the deployment of Microsoft Project 2000 and Microsoft Project Central in a corporate environment. / To ensure a successful, well-planned implementation, a companion Enterprise Planning Workbook is available at <http://www.microsoft.com/project>.
- 2: During this phase, the focus is on understanding the depth and effects of the Microsoft Project 2000 deployment at the individual, departmental, and organizational levels. You can use this information to model an effective structure for design, testing, and implementation.
- 10: During this phase, the focus is on organizing a team of diverse members that will represent the various development and deployment areas, including but not limited to project management, assessment and planning, training, technical, help desk and support, installation, and deployment.

| ID | WBS | Task | Type | Duration | Start | Finish | Predecessors | Baseline start | Baseline finish | Baseline duration | Total slack |
| --- | --- | --- | --- | --- | --- | --- | --- | --- | --- | --- | --- |
| 32 | 1.2.3 | **Preliminary Design Objectives** |  | 24.5d | 2000-01-03 | 2000-02-04 |  | 2000-01-03 | 2000-02-04 | 24.5d? | 13.5d |
| 33 | 1.2.3.1 | Map vision/scope to current computing environment |  | 1d | 2000-01-20 | 2000-01-21 | 31 | 2000-01-20 | 2000-01-21 | 1d | 0d |
| 34 | 1.2.3.2 | Determine Microsoft Project strategy |  | 1d | 2000-01-21 | 2000-01-24 | 33 | 2000-01-21 | 2000-01-24 | 1d | 0d |
| 35 | 1.2.3.3 | Determine Microsoft Project Central strategy |  | 1d? | 2000-01-24 | 2000-01-25 | 34 | 2000-01-24 | 2000-01-25 | 1d? | 0d |
| 36 | 1.2.3.4 | Determine project storage strategy |  | 1d | 2000-01-25 | 2000-01-26 | 35 | 2000-01-25 | 2000-01-26 | 1d | 0d |
| 37 | 1.2.3.5 | Determine project information dissemination strategy (Internet, intranet, e-mail) |  | 1d | 2000-01-26 | 2000-01-27 | 36 | 2000-01-26 | 2000-01-27 | 1d | 0d |
| 38 | 1.2.3.6 | **Determine File Repository Strategy** |  | 19.5d | 2000-01-03 | 2000-01-28 |  | 2000-01-03 | 2000-01-28 | 19.5d? | 20.5d |
| 39 | 1.2.3.6.1 | Determine File repository standard (I.e SQL, Oracle, MPD, MPP, etc.) |  | 1d? | 2000-01-03 | 2000-01-03 |  | 2000-01-03 | 2000-01-03 | 1d? | 96.75d |
| 40 | 1.2.3.6.2 | Determine if multiple stores are desired (I.e. Departmental, Divisional, etc.) |  | 1d? | 2000-01-03 | 2000-01-03 |  | 2000-01-03 | 2000-01-03 | 1d? | 96.75d |
| 41 | 1.2.3.6.3 | Microsoft Project file repository/location |  | 1d | 2000-01-27 | 2000-01-28 | 37 | 2000-01-27 | 2000-01-28 | 1d | 2d |
| 42 | 1.2.3.6.4 | Determine ODBC naming and access standards |  | 1d? | 2000-01-03 | 2000-01-03 |  | 2000-01-03 | 2000-01-03 | 1d? | 96.75d |
| 43 | 1.2.3.6.5 | Determine user rights |  | 1d? | 2000-01-03 | 2000-01-03 |  | 2000-01-03 | 2000-01-03 | 1d? | 96.75d |
| 44 | 1.2.3.6.6 | Analyze reporting options (standard, custom, database) |  | 1d? | 2000-01-03 | 2000-01-03 |  | 2000-01-03 | 2000-01-03 | 1d? | 96.75d |
| 45 | 1.2.3.6.7 | Determine File Repository Strategy Complete | milestone | 0d | 2000-01-03 | 2000-01-03 |  | 2000-01-03 | 2000-01-03 | 0d | 97.75d |
| 46 | 1.2.3.7 | **Microsoft Project Central Server Strategy** |  | 3d | 2000-01-27 | 2000-02-01 |  | 2000-01-27 | 2000-02-01 | 3d? | 0d |
| 47 | 1.2.3.7.1 | Determine Hardware Requirements |  | 1d? | 2000-01-27 | 2000-01-28 | 37 | 2000-01-27 | 2000-01-28 | 1d? | 0d |
| 48 | 1.2.3.7.2 | Determine Project Central Installation Location |  | 1d? | 2000-01-28 | 2000-01-31 | 47 | 2000-01-28 | 2000-01-31 | 1d? | 0d |
| 49 | 1.2.3.7.3 | Determine Site Security (https) |  | 1d? | 2000-01-31 | 2000-02-01 | 48 | 2000-01-31 | 2000-02-01 | 1d? | 0d |
| 50 | 1.2.3.7.1 | Determine server strategy complete | milestone | 0d | 2000-02-01 | 2000-02-01 | 41, 49 | 2000-02-01 | 2000-02-01 | 0d | 0d |
| 51 | 1.2.3.8 | **Determine Client Strategy** |  | 2d | 2000-02-01 | 2000-02-03 |  | 2000-02-01 | 2000-02-03 | 2d | 0d |
| 52 | 1.2.3.8.1 | Microsoft Project 2000 clients |  | 1d | 2000-02-01 | 2000-02-02 | 50 | 2000-02-01 | 2000-02-02 | 1d | 1d |
| 53 | 1.2.3.8.2 | Microsoft Project e-mail clients |  | 1d | 2000-02-01 | 2000-02-02 | 50 | 2000-02-01 | 2000-02-02 | 1d | 1d |
| 54 | 1.2.3.8.3 | Microsoft Project Central clients |  | 1d | 2000-02-01 | 2000-02-02 | 50 | 2000-02-01 | 2000-02-02 | 1d | 1d |
| 55 | 1.2.3.8.4 | Microsoft Terminal Services configuration |  | 1d | 2000-02-01 | 2000-02-02 | 50 | 2000-02-01 | 2000-02-02 | 1d | 1d |
| 56 | 1.2.3.8.5 | HTML view only |  | 1d | 2000-02-01 | 2000-02-02 | 50 | 2000-02-01 | 2000-02-02 | 1d | 1d |
| 57 | 1.2.3.8.6 | Multiple-language support |  | 1d | 2000-02-01 | 2000-02-02 | 50 | 2000-02-01 | 2000-02-02 | 1d | 0d |
| 58 | 1.2.3.8.7 | Determine project template/methodology strategy |  | 1d | 2000-02-02 | 2000-02-03 | 57 | 2000-02-02 | 2000-02-03 | 1d | 0d |
| 59 | 1.2.3.9 | Review preliminary design objectives with executive sponsor |  | 1d | 2000-02-03 | 2000-02-04 | 58, 53, 54, 55, 57, 56, 52 | 2000-02-03 | 2000-02-04 | 1d | 0d |
| 60 | 1.2.3.10 | Preliminary design objectives complete | milestone | 0d | 2000-02-04 | 2000-02-04 | 59 | 2000-02-04 | 2000-02-04 | 0d | 0d |

| ID | WBS | Task | Type | Duration | Start | Finish | Predecessors | Baseline start | Baseline finish | Baseline duration | Total slack |
| --- | --- | --- | --- | --- | --- | --- | --- | --- | --- | --- | --- |
| 61 | 1.2.4 | **Identify Coexistence Strategies** |  | 2d | 2000-02-04 | 2000-02-08 |  | 2000-02-04 | 2000-02-08 | 2d | 0d |
| 62 | 1.2.4.1 | Identify interoperability issues with previous version (Microsoft Project 98, etc.) |  | 1d | 2000-02-04 | 2000-02-07 | 60 | 2000-02-04 | 2000-02-07 | 1d | 0d |
| 63 | 1.2.4.2 | Identify interoperability issues within the company (operating systems supported, topology, protocol, etc.) |  | 1d | 2000-02-07 | 2000-02-08 | 62 | 2000-02-07 | 2000-02-08 | 1d | 0d |
| 64 | 1.2.4.3 | Identify interoperability issues with the organization's partners (topology, protocol, etc.) |  | 1d | 2000-02-07 | 2000-02-08 | 62 | 2000-02-07 | 2000-02-08 | 1d | 0d |
| 65 | 1.2.4.4 | Identify coexistence strategies complete | milestone | 0d | 2000-02-08 | 2000-02-08 | 63, 64 | 2000-02-08 | 2000-02-08 | 0d | 0d |
| 66 | 1.2.5 | **Establish Test Lab Environment** |  | 10.25d | 2000-02-08 | 2000-02-22 |  | 2000-02-08 | 2000-02-22 | 10.25d | 0d |
| 67 | 1.2.5.1 | Review current configuration documents and define a lab model |  | 1d | 2000-02-08 | 2000-02-09 | 65 | 2000-02-08 | 2000-02-09 | 1d | 0d |
| 68 | 1.2.5.2 | Select one or more lab locations |  | 2h | 2000-02-09 | 2000-02-09 | 67 | 2000-02-09 | 2000-02-09 | 2h | 0d |
| 69 | 1.2.5.3 | Determine lab space and environmental requirements |  | 2h | 2000-02-09 | 2000-02-09 | 68 | 2000-02-09 | 2000-02-09 | 2h | 0d |
| 70 | 1.2.5.4 | Determine power and network connection requirements |  | 2h | 2000-02-10 | 2000-02-10 | 69 | 2000-02-10 | 2000-02-10 | 2h | 0d |
| 71 | 1.2.5.5 | Design and document logical and physical configuration for the lab |  | 2h | 2000-02-10 | 2000-02-10 | 70 | 2000-02-10 | 2000-02-10 | 2h | 0d |
| 72 | 1.2.5.6 | Determine hardware requirements |  | 2h | 2000-02-10 | 2000-02-10 | 71 | 2000-02-10 | 2000-02-10 | 2h | 0d |
| 73 | 1.2.5.7 | Determine software requirements, including business applications and tools |  | 2h | 2000-02-10 | 2000-02-10 | 72 | 2000-02-10 | 2000-02-10 | 2h | 0d |
| 74 | 1.2.5.8 | Determine who needs to use the lab |  | 2h | 2000-02-11 | 2000-02-11 | 73 | 2000-02-11 | 2000-02-11 | 2h | 0d |
| 75 | 1.2.5.9 | Determine database/Web server requirements |  | 2h | 2000-02-11 | 2000-02-11 | 74 | 2000-02-11 | 2000-02-11 | 2h | 0d |
| 76 | 1.2.5.10 | Determine wiring and network tap plans |  | 2h | 2000-02-11 | 2000-02-11 | 75 | 2000-02-11 | 2000-02-11 | 2h | 0d |
| 77 | 1.2.5.11 | Acquire hardware, including cables and software |  | 2h | 2000-02-11 | 2000-02-11 | 76 | 2000-02-11 | 2000-02-11 | 2h | 0d |
| 78 | 1.2.5.12 | Acquire workspace equipment, such as desks, chairs, white boards, cork boards, lamps, telephones, and shelving |  | 2h | 2000-02-14 | 2000-02-14 | 77 | 2000-02-14 | 2000-02-14 | 2h | 0d |
| 79 | 1.2.5.13 | Build and configure the network |  | 1d | 2000-02-14 | 2000-02-15 | 78 | 2000-02-14 | 2000-02-15 | 1d | 0d |
| 80 | 1.2.5.14 | Test network connectivity |  | 2h | 2000-02-15 | 2000-02-15 | 79 | 2000-02-15 | 2000-02-15 | 2h | 0d |
| 81 | 1.2.5.15 | Build and configure the servers |  | 1d | 2000-02-15 | 2000-02-16 | 80 | 2000-02-15 | 2000-02-16 | 1d | 0d |
| 82 | 1.2.5.16 | Install applications and build databases on the servers |  | 1d | 2000-02-16 | 2000-02-17 | 81 | 2000-02-16 | 2000-02-17 | 1d | 0d |
| 83 | 1.2.5.17 | Install testing and administrative tools |  | 4h | 2000-02-17 | 2000-02-17 | 82 | 2000-02-17 | 2000-02-17 | 4h | 0d |
| 84 | 1.2.5.18 | Build and configure the client computers |  | 1d | 2000-02-18 | 2000-02-18 | 83 | 2000-02-18 | 2000-02-18 | 1d | 0d |
| 85 | 1.2.5.19 | Install applications on the client computers |  | 2h | 2000-02-21 | 2000-02-21 | 84 | 2000-02-21 | 2000-02-21 | 2h | 0d |
| 86 | 1.2.5.20 | Test all of the lab components |  | 4h | 2000-02-21 | 2000-02-21 | 85 | 2000-02-21 | 2000-02-21 | 4h | 0d |
| 87 | 1.2.5.21 | Assign a lab manager |  | 2h | 2000-02-21 | 2000-02-21 | 86 | 2000-02-21 | 2000-02-21 | 2h | 0d |
| 88 | 1.2.5.22 | Define a change control process for the lab |  | 2h | 2000-02-22 | 2000-02-22 | 87 | 2000-02-22 | 2000-02-22 | 2h | 0d |
| 89 | 1.2.5.23 | Create, test, and document the lab restore process |  | 4h | 2000-02-22 | 2000-02-22 | 88 | 2000-02-22 | 2000-02-22 | 4h | 0d |
| 90 | 1.2.5.24 | Establish test lab environment complete | milestone | 0d | 2000-02-22 | 2000-02-22 | 89 | 2000-02-22 | 2000-02-22 | 0d | 0d |

| ID | WBS | Task | Type | Duration | Start | Finish | Predecessors | Baseline start | Baseline finish | Baseline duration | Total slack | Free slack |
| --- | --- | --- | --- | --- | --- | --- | --- | --- | --- | --- | --- | --- |
| 91 | 1.2.6 | **Perform Risk Assessment** |  | 5d | 2000-02-08 | 2000-02-15 |  | 2000-02-08 | 2000-02-15 | 5d | 5.25d |  |
| 92 | 1.2.6.1 | Identify critical project plans |  | 1d | 2000-02-08 | 2000-02-09 | 65 | 2000-02-08 | 2000-02-09 | 1d | 5.25d | 0d |
| 93 | 1.2.6.2 | Identify and analyze potential risks |  | 1d | 2000-02-09 | 2000-02-10 | 92 | 2000-02-09 | 2000-02-10 | 1d | 5.25d | 0d |
| 94 | 1.2.6.3 | Quantify potential impact of the risks |  | 1d | 2000-02-10 | 2000-02-11 | 93 | 2000-02-10 | 2000-02-11 | 1d | 5.25d | 0d |
| 95 | 1.2.6.4 | Detail escalation processes |  | 1d | 2000-02-11 | 2000-02-14 | 94 | 2000-02-11 | 2000-02-14 | 1d | 5.25d | 0d |
| 96 | 1.2.6.5 | Document risk assessment |  | 1d | 2000-02-14 | 2000-02-15 | 95 | 2000-02-14 | 2000-02-15 | 1d | 5.25d | 0d |
| 97 | 1.2.6.6 | Risk assessment complete | milestone | 0d | 2000-02-15 | 2000-02-15 | 96 | 2000-02-15 | 2000-02-15 | 0d | 5.25d |  |
| 98 | 1.2.7 | **Define Communication Strategy** |  | 5d | 2000-02-08 | 2000-02-15 |  | 2000-02-08 | 2000-02-15 | 5d | 5.25d |  |
| 99 | 1.2.7.1 | Define communication strategy for each phase |  | 1d | 2000-02-08 | 2000-02-09 | 65 | 2000-02-08 | 2000-02-09 | 1d | 5.25d | 0d |
| 100 | 1.2.7.2 | Define communication audiences |  | 1d | 2000-02-09 | 2000-02-10 | 99 | 2000-02-09 | 2000-02-10 | 1d | 5.25d | 0d |
| 101 | 1.2.7.3 | Define communication delivery mechanism |  | 1d | 2000-02-10 | 2000-02-11 | 100 | 2000-02-10 | 2000-02-11 | 1d | 5.25d | 0d |
| 102 | 1.2.7.4 | Establish communication timeline |  | 1d | 2000-02-11 | 2000-02-14 | 101 | 2000-02-11 | 2000-02-14 | 1d | 5.25d | 0d |
| 103 | 1.2.7.5 | Document communication strategy/standards |  | 1d | 2000-02-14 | 2000-02-15 | 102 | 2000-02-14 | 2000-02-15 | 1d | 5.25d | 0d |
| 104 | 1.2.7.6 | Communication strategy complete | milestone | 0d | 2000-02-15 | 2000-02-15 | 103 | 2000-02-15 | 2000-02-15 | 0d | 5.25d |  |
| 105 | 1.2.8 | **Define Education/Training Strategy** |  | 4d | 2000-02-08 | 2000-02-14 |  | 2000-02-08 | 2000-02-14 | 4d | 67.25d |  |
| 106 | 1.2.8.1 | Define education strategy for deployment demographics (administrators, help desk, end-users) |  | 1d | 2000-02-08 | 2000-02-09 | 65, 60 | 2000-02-08 | 2000-02-09 | 1d | 67.25d | 0d |
| 107 | 1.2.8.2 | Define education delivery mechanism |  | 1d | 2000-02-09 | 2000-02-10 | 106 | 2000-02-09 | 2000-02-10 | 1d | 67.25d | 0d |
| 108 | 1.2.8.3 | Establish education timeline by phase |  | 1d | 2000-02-10 | 2000-02-11 | 107 | 2000-02-10 | 2000-02-11 | 1d | 67.25d | 0d |
| 109 | 1.2.8.4 | Document education strategy/standards |  | 1d | 2000-02-11 | 2000-02-14 | 108 | 2000-02-11 | 2000-02-14 | 1d | 67.25d |  |
| 110 | 1.2.9 | Planning complete | milestone | 0d | 2000-02-22 | 2000-02-22 | 104, 97, 90 | 2000-02-22 | 2000-02-22 | 0d | 0d |  |
| 111 | 1.3 | **Development/Testing** |  | 11d? | 2000-02-22 | 2000-03-08 |  | 2000-02-22 | 2000-03-08 | 11d? | 0d |  |
| 112 | 1.3.1 | **Overall** |  | 8d | 2000-02-22 | 2000-03-03 | 110 | 2000-02-22 | 2000-03-03 | 8d | 0d |  |
| 113 | 1.3.1.1 | Review planning documents |  | 1d | 2000-02-22 | 2000-02-23 |  | 2000-02-22 | 2000-02-23 | 1d | 0d |  |
| 114 | 1.3.1.2 | Identify development areas (templates, Web, etc.) |  | 1d | 2000-02-23 | 2000-02-24 | 113 | 2000-02-23 | 2000-02-24 | 1d | 0d |  |
| 115 | 1.3.1.3 | Assign development staff |  | 1d | 2000-02-24 | 2000-02-25 | 114 | 2000-02-24 | 2000-02-25 | 1d | 0d |  |
| 116 | 1.3.1.4 | Develop Training Curriculum |  | 1w | 2000-02-25 | 2000-03-03 | 115 | 2000-02-25 | 2000-03-03 | 1w | 3d | 0d |
| 117 | 1.3.1.5 | Overall Development/Testing Complete | milestone | 0d | 2000-03-03 | 2000-03-03 | 116 | 2000-03-03 | 2000-03-03 | 0d | 53d |  |

Notes:
- 111: During this phase, you focus on developing the custom Microsoft Project 2000 installation or installations for the organization, specifically defining any nuances in configurations for multiple installation definitions. / Testing of those installation packages and field testing parameters are also specified.

| ID | WBS | Task | Type | Duration | Start | Finish | Predecessors | Baseline start | Baseline finish | Baseline duration | Total slack | Free slack |
| --- | --- | --- | --- | --- | --- | --- | --- | --- | --- | --- | --- | --- |
| 118 | 1.3.4 | **Infrastructure** |  | 4d? | 2000-02-25 | 2000-03-02 |  | 2000-02-25 | 2000-03-02 | 4d? | 4d |  |
| 119 | 1.3.4.1 | Identify/Purchase IIS Servers for Project Central |  | 1d? | 2000-02-25 | 2000-02-28 | 115 | 2000-02-25 | 2000-02-28 | 1d? | 4d | 0d |
| 120 | 1.3.4.2 | Identify/Purchase data repository servers |  | 1d? | 2000-02-28 | 2000-02-29 | 119 | 2000-02-28 | 2000-02-29 | 1d? | 4d | 0d |
| 121 | 1.3.2.3 | Identify Internet Explorer Connection Settings |  | 1d? | 2000-02-29 | 2000-03-01 | 120 | 2000-02-29 | 2000-03-01 | 1d? | 4d | 0d |
| 122 | 1.3.4.3 | Develop solution, enhancement, etc. |  | 1d | 2000-03-01 | 2000-03-02 | 121 | 2000-03-01 | 2000-03-02 | 1d | 4d |  |
| 123 | 1.3.5 | **Desktop** |  | 2d | 2000-02-25 | 2000-02-29 |  | 2000-02-25 | 2000-02-29 | 2d | 6d |  |
| 124 | 1.3.5.1 | Create transform using Custom Installation Wizard |  | 1d | 2000-02-25 | 2000-02-28 | 115 | 2000-02-25 | 2000-02-28 | 1d | 6d | 0d |
| 125 | 1.3.5.2 | Test solution, enhancement, etc. |  | 1d | 2000-02-28 | 2000-02-29 | 124 | 2000-02-28 | 2000-02-29 | 1d | 6d |  |
| 126 | 1.3.4 | **Project Central Configuration** |  | 8d? | 2000-02-25 | 2000-03-08 |  | 2000-02-25 | 2000-03-08 | 8d? | 0d |  |
| 127 | 1.3.4.1 | Define Client Browser Support |  | 1d? | 2000-02-25 | 2000-02-28 | 115 | 2000-02-25 | 2000-02-28 | 1d? | 0d |  |
| 128 | 1.3.4.2 | Define Security (logon) Method |  | 1d? | 2000-02-28 | 2000-02-29 | 127 | 2000-02-28 | 2000-02-29 | 1d? | 0d |  |
| 129 | 1.3.4.3 | Define User Groups |  | 1d? | 2000-02-29 | 2000-03-01 | 128 | 2000-02-29 | 2000-03-01 | 1d? | 0d |  |
| 130 | 1.3.4.4 | Define Users |  | 1d? | 2000-03-01 | 2000-03-02 | 129 | 2000-03-01 | 2000-03-02 | 1d? | 0d |  |
| 131 | 1.3.4.5 | Define User Rights |  | 1d? | 2000-03-02 | 2000-03-03 | 130 | 2000-03-02 | 2000-03-03 | 1d? | 0d |  |
| 132 | 1.3.4.6 | Define Project Views |  | 1d? | 2000-03-03 | 2000-03-06 | 131 | 2000-03-03 | 2000-03-06 | 1d? | 0d |  |
| 133 | 1.3.4.7 | Define Status Reports |  | 1d? | 2000-03-06 | 2000-03-07 | 132 | 2000-03-06 | 2000-03-07 | 1d? | 0d |  |
| 134 | 1.3.4.8 | Project Central Configuration Complete |  | 1d? | 2000-03-07 | 2000-03-08 | 133 | 2000-03-07 | 2000-03-08 | 1d? | 0d |  |
| 135 | 1.3.5 | Development/Testing Complete | milestone | 0d | 2000-03-08 | 2000-03-08 | 122, 125, 134, 116 | 2000-03-08 | 2000-03-08 | 0d | 0d |  |
| 136 | 1.4 | **Proof of Concept** |  | 13d | 2000-03-08 | 2000-03-27 |  | 2000-03-08 | 2000-03-27 | 13d | 0d |  |
| 137 | 1.4.1 | **Proof-of-Concept Preparation** |  | 4d | 2000-03-08 | 2000-03-14 |  | 2000-03-08 | 2000-03-14 | 4d | 0d |  |
| 138 | 1.4.1.1 | Prepare a test plan and checklists based on development/design solutions |  | 1d | 2000-03-08 | 2000-03-09 | 135 | 2000-03-08 | 2000-03-09 | 1d | 0d |  |
| 139 | 1.4.1.2 | Document features and components to test |  | 1d | 2000-03-09 | 2000-03-10 | 138 | 2000-03-09 | 2000-03-10 | 1d | 0d |  |
| 140 | 1.4.1.3 | Secure testing personnel |  | 1d | 2000-03-10 | 2000-03-13 | 139 | 2000-03-10 | 2000-03-13 | 1d | 0d |  |
| 141 | 1.4.1.4 | **Ensure Testing Lab Environment Simulates Proposed Environment** |  | 1d | 2000-03-13 | 2000-03-14 | 140 | 2000-03-13 | 2000-03-14 | 1d | 0d |  |
| 142 | 1.4.1.4.1 | Server hardware and drivers |  | 1d | 2000-03-13 | 2000-03-14 | 140 | 2000-03-13 | 2000-03-14 | 1d | 0d |  |
| 143 | 1.4.1.4.2 | Server function/strategy |  | 1d | 2000-03-13 | 2000-03-14 | 140 | 2000-03-13 | 2000-03-14 | 1d | 0d |  |
| 144 | 1.4.1.4.3 | Mixed environment |  | 1d | 2000-03-13 | 2000-03-14 | 140 | 2000-03-13 | 2000-03-14 | 1d | 0d |  |
| 145 | 1.4.1.4.4 | Client computer configuration |  | 1d | 2000-03-13 | 2000-03-14 | 140 | 2000-03-13 | 2000-03-14 | 1d | 0d |  |
| 146 | 1.4.1.4.5 | Network topology and protocols |  | 1d | 2000-03-13 | 2000-03-14 | 140 | 2000-03-13 | 2000-03-14 | 1d | 0d |  |
| 147 | 1.4.1.4.6 | Wide-area network connectivity |  | 1d | 2000-03-13 | 2000-03-14 | 140 | 2000-03-13 | 2000-03-14 | 1d | 0d |  |
| 148 | 1.4.1.4.7 | Remote connectivity |  | 1d | 2000-03-13 | 2000-03-14 | 140 | 2000-03-13 | 2000-03-14 | 1d | 0d |  |
| 149 | 1.4.1.4.8 | Peripherals |  | 1d | 2000-03-13 | 2000-03-14 | 140 | 2000-03-13 | 2000-03-14 | 1d | 0d |  |
| 150 | 1.4.1.4.9 | Terminal services |  | 1d | 2000-03-13 | 2000-03-14 | 140 | 2000-03-13 | 2000-03-14 | 1d | 0d |  |
| 151 | 1.4.1.4.10 | Ensure testing lab environment simulates proposed environment complete | milestone | 0d | 2000-03-14 | 2000-03-14 | 142, 143, 144, 145, 146, 147, 148, 149, 150 | 2000-03-14 | 2000-03-14 | 0d | 0d |  |
| 152 | 1.4.1.5 | Proof-of-concept preparation complete | milestone | 0d | 2000-03-14 | 2000-03-14 | 151 | 2000-03-14 | 2000-03-14 | 0d | 0d |  |

Notes:
- 136: During this phase, you create the proof-of-concept environment to evaluate the various components discussed earlier in the plan. For proper evaluation, the proof-of-concept environment should be a scaled-back version of the full Microsoft Project 2000 model.

| ID | WBS | Task | Type | Duration | Start | Finish | Predecessors | Baseline start | Baseline finish | Baseline duration | Total slack | Free slack |
| --- | --- | --- | --- | --- | --- | --- | --- | --- | --- | --- | --- | --- |
| 153 | 1.4.2 | **Deploy Development Solution to Proof-of-Concept Lab Machines** |  | 6d | 2000-03-14 | 2000-03-22 |  | 2000-03-14 | 2000-03-22 | 6d | 0d |  |
| 154 | 1.4.2.1 | Perform tests to test plan specification |  | 1d | 2000-03-14 | 2000-03-15 | 152 | 2000-03-14 | 2000-03-15 | 1d | 0d |  |
| 155 | 1.4.2.2 | Analyze results |  | 1d | 2000-03-15 | 2000-03-16 | 154 | 2000-03-15 | 2000-03-16 | 1d | 0d |  |
| 156 | 1.4.2.3 | **Mitigate Results** |  | 4d | 2000-03-16 | 2000-03-22 |  | 2000-03-16 | 2000-03-22 | 4d | 0d |  |
| 157 | 1.4.2.3.1 | **Test Case Problem** |  | 4d | 2000-03-16 | 2000-03-22 |  | 2000-03-16 | 2000-03-22 | 4d | 0d |  |
| 158 | 1.4.2.3.1.1 | Document in proof-of-concept tracking system |  | 1d | 2000-03-16 | 2000-03-17 | 155 | 2000-03-16 | 2000-03-17 | 1d | 0d |  |
| 159 | 1.4.2.3.1.2 | Revise test case |  | 1d | 2000-03-17 | 2000-03-20 | 158 | 2000-03-17 | 2000-03-20 | 1d | 0d |  |
| 160 | 1.4.2.3.1.3 | Rerun the test |  | 1d | 2000-03-20 | 2000-03-21 | 159 | 2000-03-20 | 2000-03-21 | 1d | 0d |  |
| 161 | 1.4.2.3.1.4 | Document results/changes |  | 1d | 2000-03-21 | 2000-03-22 | 160 | 2000-03-21 | 2000-03-22 | 1d | 0d |  |
| 162 | 1.4.2.3.1.5 | Test case problem complete | milestone | 0d | 2000-03-22 | 2000-03-22 | 161 | 2000-03-22 | 2000-03-22 | 0d | 0d |  |
| 163 | 1.4.2.3.2 | **Development/Design Problem** |  | 4d | 2000-03-16 | 2000-03-22 |  | 2000-03-16 | 2000-03-22 | 4d | 0d |  |
| 164 | 1.4.2.3.2.1 | Document in proof-of-concept tracking system |  | 1d | 2000-03-16 | 2000-03-17 | 155 | 2000-03-16 | 2000-03-17 | 1d | 0d |  |
| 165 | 1.4.2.3.2.2 | Escalate development/design issues |  | 1d | 2000-03-17 | 2000-03-20 | 164 | 2000-03-17 | 2000-03-20 | 1d | 0d |  |
| 166 | 1.4.2.3.2.3 | Prioritize/risk analysis |  | 1d | 2000-03-20 | 2000-03-21 | 165 | 2000-03-20 | 2000-03-21 | 1d | 0d |  |
| 167 | 1.4.2.3.2.4 | Track resolution |  | 1d | 2000-03-21 | 2000-03-22 | 166 | 2000-03-21 | 2000-03-22 | 1d | 0d |  |
| 168 | 1.4.2.3.2.5 | Development/design problem complete | milestone | 0d | 2000-03-22 | 2000-03-22 | 167 | 2000-03-22 | 2000-03-22 | 0d | 0d |  |
| 169 | 1.4.2.3.3 | Deploy development solution to proof-of-concept lab machines complete | milestone | 0d | 2000-03-22 | 2000-03-22 | 162, 168 | 2000-03-22 | 2000-03-22 | 0d | 0d |  |
| 170 | 1.4.3 | **Perform Full-Cycle Risk Assessment** |  | 3d | 2000-03-22 | 2000-03-27 |  | 2000-03-22 | 2000-03-27 | 3d | 0d |  |
| 171 | 1.4.3.1 | Document lessons learned |  | 1d | 2000-03-22 | 2000-03-23 | 169 | 2000-03-22 | 2000-03-23 | 1d | 0d |  |
| 172 | 1.4.3.2 | Document modifications |  | 1d | 2000-03-23 | 2000-03-24 | 171 | 2000-03-23 | 2000-03-24 | 1d | 0d |  |
| 173 | 1.4.3.3 | Address readiness to proceed to pilot |  | 1d | 2000-03-24 | 2000-03-27 | 172 | 2000-03-24 | 2000-03-27 | 1d | 0d |  |
| 174 | 1.4.3.4 | Perform full-cycle risk assessment complete | milestone | 0d | 2000-03-27 | 2000-03-27 | 173 | 2000-03-27 | 2000-03-27 | 0d | 0d |  |
| 175 | 1.4.4 | Proof of concept complete | milestone | 0d | 2000-03-27 | 2000-03-27 | 174 | 2000-03-27 | 2000-03-27 | 0d | 0d |  |
| 176 | 1.5 | **Pilot** |  | 25d | 2000-03-27 | 2000-05-01 |  | 2000-03-27 | 2000-05-01 | 25d | 0d |  |
| 177 | 1.5.1 | **Planning** |  | 12d | 2000-03-27 | 2000-04-12 |  | 2000-03-27 | 2000-04-12 | 12d | 0d |  |
| 178 | 1.5.1.1 | Identify pilot scope and objectives |  | 1d | 2000-03-27 | 2000-03-28 | 175 | 2000-03-27 | 2000-03-28 | 1d | 0d |  |
| 179 | 1.5.1.2 | Identify pilot groups, individuals, resources, equipment |  | 1d | 2000-03-28 | 2000-03-29 | 178 | 2000-03-28 | 2000-03-29 | 1d | 8d | 0d |
| 180 | 1.5.1.3 | Document resources and tasks |  | 1d | 2000-03-29 | 2000-03-30 | 178, 179 | 2000-03-29 | 2000-03-30 | 1d | 8d | 0d |
| 181 | 1.5.1.4 | Develop communications materials for user community (frequently asked questions, Web site, e-mail, etc.) |  | 1d | 2000-03-30 | 2000-03-31 | 178, 180 | 2000-03-30 | 2000-03-31 | 1d | 8d |  |
| 182 | 1.5.1.5 | Develop the user support plan |  | 1d | 2000-03-28 | 2000-03-29 | 178 | 2000-03-28 | 2000-03-29 | 1d | 10d |  |
| 183 | 1.5.1.6 | Develop the training plan |  | 1d | 2000-03-28 | 2000-03-29 | 178 | 2000-03-28 | 2000-03-29 | 1d | 0d |  |

Notes:
- 176: During this phase, you conduct a pilot to evaluate the various components discussed earlier in the plan. For proper evaluation, the pilot environment should be a scaled-back version of the full Microsoft Project 2000 deployment model.

| ID | WBS | Task | Type | Duration | Start | Finish | Predecessors | Baseline start | Baseline finish | Baseline duration | Total slack |
| --- | --- | --- | --- | --- | --- | --- | --- | --- | --- | --- | --- |
| 184 | 1.5.1.7 | **Develop the Rollout Process** |  | 8d | 2000-03-29 | 2000-04-10 |  | 2000-03-29 | 2000-04-10 | 8d | 0d |
| 185 | 1.5.1.7.1 | Identify tools and supplies the installer needs |  | 1d | 2000-03-29 | 2000-03-30 | 183 | 2000-03-29 | 2000-03-30 | 1d | 0d |
| 186 | 1.5.1.7.2 | Identify lists of scripts and their locations |  | 1d | 2000-03-30 | 2000-03-31 | 185 | 2000-03-30 | 2000-03-31 | 1d | 0d |
| 187 | 1.5.1.7.3 | Identify backups to be made before and during deployment |  | 1d | 2000-03-31 | 2000-04-03 | 186 | 2000-03-31 | 2000-04-03 | 1d | 0d |
| 188 | 1.5.1.7.4 | Document steps for migrating to Microsoft Project 2000 |  | 1d | 2000-04-03 | 2000-04-04 | 187 | 2000-04-03 | 2000-04-04 | 1d | 0d |
| 189 | 1.5.1.7.5 | Document steps for performing manual and automated computer upgrades |  | 1d | 2000-04-04 | 2000-04-05 | 188 | 2000-04-04 | 2000-04-05 | 1d | 0d |
| 190 | 1.5.1.7.6 | Document installer acceptance tests |  | 1d | 2000-04-05 | 2000-04-06 | 189 | 2000-04-05 | 2000-04-06 | 1d | 0d |
| 191 | 1.5.1.7.7 | Document operational procedures for installers and administrators |  | 1d | 2000-04-06 | 2000-04-07 | 190 | 2000-04-06 | 2000-04-07 | 1d | 0d |
| 192 | 1.5.1.7.8 | Document steps for backing out if pilot fails |  | 1d | 2000-04-07 | 2000-04-10 | 191 | 2000-04-07 | 2000-04-10 | 1d | 0d |
| 193 | 1.5.1.7.9 | Develop the rollout process complete | milestone | 0d | 2000-04-10 | 2000-04-10 | 192 | 2000-04-10 | 2000-04-10 | 0d | 0d |
| 194 | 1.5.1.8 | Identify known risks and contingency plans for them |  | 1d | 2000-04-10 | 2000-04-11 | 193 | 2000-04-10 | 2000-04-11 | 1d | 0d |
| 195 | 1.5.1.9 | Develop rollback plan |  | 1d | 2000-04-11 | 2000-04-12 | 194 | 2000-04-11 | 2000-04-12 | 1d | 0d |
| 196 | 1.5.1.10 | Pilot planning complete | milestone | 0d | 2000-04-12 | 2000-04-12 | 181, 182, 183, 185, 186, 195 | 2000-04-12 | 2000-04-12 | 0d | 0d |
| 197 | 1.5.2 | **Deployment** |  | 7d | 2000-04-12 | 2000-04-21 |  | 2000-04-12 | 2000-04-21 | 7d | 0d |
| 198 | 1.5.2.1 | Communicate with pilot users |  | 1d | 2000-04-12 | 2000-04-13 | 196 | 2000-04-12 | 2000-04-13 | 1d | 4d |
| 199 | 1.5.2.2 | Conduct user training |  | 1w | 2000-04-12 | 2000-04-19 | 196 | 2000-04-12 | 2000-04-19 | 1w | 0d |
| 200 | 1.5.2.3 | Ensure support organization is prepared |  | 1d | 2000-04-12 | 2000-04-13 | 196 | 2000-04-12 | 2000-04-13 | 1d | 4d |
| 201 | 1.5.2.4 | Prepare pilot site or sites |  | 1d | 2000-04-19 | 2000-04-20 | 198, 199, 200 | 2000-04-19 | 2000-04-20 | 1d | 0d |
| 202 | 1.5.2.5 | Deploy the rollout process |  | 1d | 2000-04-20 | 2000-04-21 | 201 | 2000-04-20 | 2000-04-21 | 1d | 0d |
| 203 | 1.5.2.6 | Pilot deployment complete | milestone | 0d | 2000-04-21 | 2000-04-21 | 202 | 2000-04-21 | 2000-04-21 | 0d | 0d |
| 204 | 1.5.3 | **Evaluate the Pilot** |  | 2d | 2000-04-21 | 2000-04-25 |  | 2000-04-21 | 2000-04-25 | 2d | 0d |
| 205 | 1.5.3.1 | Conduct desktop test scenarios |  | 1d | 2000-04-21 | 2000-04-24 | 203 | 2000-04-21 | 2000-04-24 | 1d | 0d |
| 206 | 1.5.3.2 | Conduct server test scenarios |  | 1d | 2000-04-21 | 2000-04-24 | 203 | 2000-04-21 | 2000-04-24 | 1d | 0d |
| 207 | 1.5.3.3 | Conduct third-party application test scenarios |  | 1d | 2000-04-21 | 2000-04-24 | 203 | 2000-04-21 | 2000-04-24 | 1d | 0d |
| 208 | 1.5.3.4 | Conduct custom application test scenarios |  | 1d | 2000-04-21 | 2000-04-24 | 203 | 2000-04-21 | 2000-04-24 | 1d | 0d |
| 209 | 1.5.3.5 | Conduct coexistence test scenarios |  | 1d | 2000-04-21 | 2000-04-24 | 203 | 2000-04-21 | 2000-04-24 | 1d | 0d |
| 210 | 1.5.3.6 | Identify scope changes |  | 1d | 2000-04-24 | 2000-04-25 | 205, 206, 207, 208, 209 | 2000-04-24 | 2000-04-25 | 1d | 0d |
| 211 | 1.5.3.7 | Identify cost factors |  | 1d | 2000-04-24 | 2000-04-25 | 205, 206, 207, 208, 209 | 2000-04-24 | 2000-04-25 | 1d | 0d |
| 212 | 1.5.3.8 | Identify interoperability issues |  | 1d | 2000-04-24 | 2000-04-25 | 205, 206, 207, 208, 209 | 2000-04-24 | 2000-04-25 | 1d | 0d |
| 213 | 1.5.3.9 | Identify unanticipated downtime |  | 1d | 2000-04-24 | 2000-04-25 | 205, 206, 207, 208, 209 | 2000-04-24 | 2000-04-25 | 1d | 0d |
| 214 | 1.5.3.10 | Pilot test complete | milestone | 0d | 2000-04-25 | 2000-04-25 | 210, 211, 212, 213 | 2000-04-25 | 2000-04-25 | 0d | 0d |

| ID | WBS | Task | Type | Duration | Start | Finish | Predecessors | Baseline start | Baseline finish | Baseline duration | Total slack | Free slack |
| --- | --- | --- | --- | --- | --- | --- | --- | --- | --- | --- | --- | --- |
| 215 | 1.5.4 | **Post-Pilot Evaluation** |  | 4d | 2000-04-25 | 2000-05-01 |  | 2000-04-25 | 2000-05-01 | 4d | 0d |  |
| 216 | 1.5.4.1 | Obtain user feedback |  | 1d | 2000-04-25 | 2000-04-26 | 214 | 2000-04-25 | 2000-04-26 | 1d | 0d |  |
| 217 | 1.5.4.2 | Evaluate lessons learned |  | 1d | 2000-04-26 | 2000-04-27 | 216 | 2000-04-26 | 2000-04-27 | 1d | 0d |  |
| 218 | 1.5.4.3 | Modify items as necessary |  | 1d | 2000-04-27 | 2000-04-28 | 217 | 2000-04-27 | 2000-04-28 | 1d | 0d |  |
| 219 | 1.5.4.4 | Document recommendations for next steps |  | 1d | 2000-04-28 | 2000-05-01 | 218 | 2000-04-28 | 2000-05-01 | 1d | 0d |  |
| 220 | 1.5.4.5 | Post-pilot evaluation complete | milestone | 0d | 2000-05-01 | 2000-05-01 | 219 | 2000-05-01 | 2000-05-01 | 0d | 0d |  |
| 221 | 1.5.5 | Pilot complete | milestone | 0d | 2000-05-01 | 2000-05-01 | 220 | 2000-05-01 | 2000-05-01 | 0d | 0d |  |
| 222 | 1.6 | **Deployment** |  | 8d | 2000-05-01 | 2000-05-11 |  | 2000-05-01 | 2000-05-11 | 8d | 0d |  |
| 223 | 1.6.1 | **Communications** |  | 2d | 2000-05-01 | 2000-05-03 |  | 2000-05-01 | 2000-05-03 | 2d | 0d |  |
| 224 | 1.6.1.1 | Review communications strategy document |  | 1d | 2000-05-01 | 2000-05-02 | 221 | 2000-05-01 | 2000-05-02 | 1d | 0d |  |
| 225 | 1.6.1.2 | Start communications |  | 1d | 2000-05-02 | 2000-05-03 | 224 | 2000-05-02 | 2000-05-03 | 1d | 0d |  |
| 226 | 1.6.1.3 | Communications complete | milestone | 0d | 2000-05-03 | 2000-05-03 | 225 | 2000-05-03 | 2000-05-03 | 0d | 0d |  |
| 227 | 1.6.2 | **Education/Training** |  | 3d | 2000-05-03 | 2000-05-08 |  | 2000-05-03 | 2000-05-08 | 3d | 3d |  |
| 228 | 1.6.2.1 | Review education/training strategy document |  | 1d | 2000-05-03 | 2000-05-04 | 226 | 2000-05-03 | 2000-05-04 | 1d | 3d | 0d |
| 229 | 1.6.2.2 | Conduct administrative training |  | 1d | 2000-05-04 | 2000-05-05 | 228 | 2000-05-04 | 2000-05-05 | 1d | 3d | 0d |
| 230 | 1.6.2.3 | Conduct user training |  | 1d | 2000-05-05 | 2000-05-08 | 229, 228 | 2000-05-05 | 2000-05-08 | 1d | 3d | 0d |
| 231 | 1.6.2.4 | Education/training complete | milestone | 0d | 2000-05-08 | 2000-05-08 | 230, 229 | 2000-05-08 | 2000-05-08 | 0d | 3d |  |
| 232 | 1.6.3 | **Install Microsoft Project 2000 Components** |  | 6d | 2000-05-03 | 2000-05-11 |  | 2000-05-03 | 2000-05-11 | 6d | 0d |  |
| 233 | 1.6.3.1 | Server side installation |  | 1d | 2000-05-03 | 2000-05-04 | 226 | 2000-05-03 | 2000-05-04 | 1d | 0d |  |
| 234 | 1.6.3.2 | Verify server installation |  | 1d | 2000-05-04 | 2000-05-05 | 233 | 2000-05-04 | 2000-05-05 | 1d | 0d |  |
| 235 | 1.6.3.3 | Client side installation |  | 1d | 2000-05-05 | 2000-05-08 | 234 | 2000-05-05 | 2000-05-08 | 1d | 0d |  |
| 236 | 1.6.3.4 | Verify client installation |  | 1d | 2000-05-08 | 2000-05-09 | 235 | 2000-05-08 | 2000-05-09 | 1d | 0d |  |
| 237 | 1.6.3.5 | Install custom components/add-ons |  | 1d | 2000-05-09 | 2000-05-10 | 236 | 2000-05-09 | 2000-05-10 | 1d | 0d |  |
| 238 | 1.6.3.6 | Verify custom components/add-ons |  | 1d | 2000-05-10 | 2000-05-11 | 237 | 2000-05-10 | 2000-05-11 | 1d | 0d |  |
| 239 | 1.6.3.7 | Install Microsoft Project 2000 components complete | milestone | 0d | 2000-05-11 | 2000-05-11 | 238 | 2000-05-11 | 2000-05-11 | 0d | 0d |  |
| 240 | 1.6.4 | Deployment complete | milestone | 0d | 2000-05-11 | 2000-05-11 | 239, 231 | 2000-05-11 | 2000-05-11 | 0d | 0d |  |

Notes:
- 222: This is the final phase for product deployment. It will be modeled on the information gathered during the previous phases, including the proof-of-concept and pilot phases.

| ID | WBS | Task | Type | Duration | Start | Finish | Predecessors | Baseline start | Baseline finish | Baseline duration | Total slack |
| --- | --- | --- | --- | --- | --- | --- | --- | --- | --- | --- | --- |
| 241 | 1.7 | **Post-Implementation Review** |  | 4d | 2000-05-11 | 2000-05-17 |  | 2000-05-11 | 2000-05-17 | 4d | 0d |
| 242 | 1.7.1 | Obtain user feedback |  | 1d | 2000-05-11 | 2000-05-12 | 240 | 2000-05-11 | 2000-05-12 | 1d | 0d |
| 243 | 1.7.2 | Evaluate lessons learned |  | 1d | 2000-05-12 | 2000-05-15 | 242 | 2000-05-12 | 2000-05-15 | 1d | 0d |
| 244 | 1.7.3 | Modify items as necessary |  | 1d | 2000-05-15 | 2000-05-16 | 243 | 2000-05-15 | 2000-05-16 | 1d | 0d |
| 245 | 1.7.4 | Establish ongoing infrastructure planning team |  | 1d | 2000-05-16 | 2000-05-17 | 244 | 2000-05-16 | 2000-05-17 | 1d | 0d |
| 246 | 1.7.5 | Post-implementation review complete | milestone | 0d | 2000-05-17 | 2000-05-17 | 245 | 2000-05-17 | 2000-05-17 | 0d | 0d |
| 247 | 1.8 | Deploying Microsoft Project 2000 and Project Central in the Enterprise complete | milestone | 0d | 2000-05-17 | 2000-05-17 | 246 | 2000-05-17 | 2000-05-17 | 0d | 0d |

Notes:
- 241: This is the final phase for the entire project. During this phase, you will review the project and document the lessons learned to provide a foundation for future deployment projects.
