# MSF Project Schedule

Schedule from MS Project, 2003-11-27 to 2004-03-05.
EDS

## Calendars

- Standard: Mon-Fri 08:00-12:00, 13:00-17:00; Sat-Sun off.

## Resources

| Resource | Notes |
| --- | --- |
| Product Management | The key goal of the product management role cluster is satisfied customers. Projects must meet the needs of customers in order to be successful. However, first the customer must be clearly identified and understood! In some cases the customer requesting a solution or set of features may be different from the sponsor who is paying or supporting effort. Thus there must be a clear distinction and requirements analysis for the success factors for both parties. Only then can the responsibilities of setting and meeting the expectations be assigned to the appropriate function areas. It is possible to meet budget and time goals but still be unsuccessful if customer and business needs have not been met. |
| Program Management | The focus of the program management role is to meet the goal of delivering the solution within project constraints. This can be viewed as ensuring that the project sponsor is satisfied with the outcome of the project. To meet this goal, program management owns and drives the schedule, the feature set, and the budget for the project. Program management ensures that the right solution is delivered at the right time and that the project sponsors expectations are understood and managed throughout the project. Descriptions of selected functional areas are shown below. |
| Development | The build to specification goal is the focus for the development role cluster during an MSF project. To succeed in meeting its quality goal, the role of development is to build a solution that meets the customers expectations and specifications as expressed in the functional specification. The development role cluster adheres to the solution architecture and designs that, together with the function specification, form the overall specifications of the solution. |
| Test | The goal of the test role cluster is to approve for release only after all product quality issues are identified and addressed. All software is delivered with defects. A key goal is to ensure those defects are identified and addressed prior to releasing the product. Addressing can involve everything from fixing the defect in question to documenting work-around solutions. Delivering a known defect that has been addressed along with a work-around solution is preferable to delivering a product containing unidentified defects that may surprise the team and customer later. |
| User Experience | The goal of the user experience role cluster is enhanced user effectiveness. User experience is comprised of six functional areas: Accessibility, internationalization, technical communications, training, usability, and graphic design. The user experience role cluster has several responsibilities within each functional area that must be managed for the solution to be successful. |
| Release Management | The goal of the release management role cluster is smooth deployment and on-going operations. Release management is the role that directly involves operations on the MSF team. |

## Schedule

| ID | WBS | Task | Type | Duration | Start | Finish | Predecessors | Total slack | Free slack | Resources | Work |
| --- | --- | --- | --- | --- | --- | --- | --- | --- | --- | --- | --- |
| 1 | 1 | **Project Schedule** |  | 72d | 2003-11-27 | 2004-03-05 |  | 0d |  |  | 784h |
| 2 | 1.1 | **Envisioning** |  | 18d | 2003-11-27 | 2003-12-22 |  | 0d |  |  | 304h |
| 3 | 1.1.1 | Organize Core Team |  | 1d | 2003-11-27 | 2003-11-27 |  | 0d |  | Program Management | 8h |
| 4 | 1.1.2 | **Master Project Approach** |  | 5d | 2003-11-28 | 2003-12-04 | 3 | 0d |  |  | 72h |
| 5 | 1.1.2.1 | Development Approach |  | 1d | 2003-11-28 | 2003-11-28 |  | 0d |  | Development | 8h |
| 6 | 1.1.2.2 | Test Approach |  | 1d | 2003-11-28 | 2003-11-28 | 5FF | 2d | 0d | Test | 8h |
| 7 | 1.1.2.3 | Training Approach |  | 1d | 2003-11-28 | 2003-11-28 | 6FF | 2d | 0d | User Experience | 8h |
| 8 | 1.1.2.4 | User Support Approach |  | 1d | 2003-12-01 | 2003-12-01 | 7FF | 4d | 0d | User Experience | 8h |
| 9 | 1.1.2.5 | Communication Approach |  | 1d | 2003-12-01 | 2003-12-01 | 8FF | 5d | 0d | Product Management | 8h |
| 10 | 1.1.2.6 | Deployment Approach |  | 1d | 2003-12-01 | 2003-12-01 | 9FF | 5d | 0d | Release Management | 8h |
| 11 | 1.1.2.7 | Operations Approach |  | 1d | 2003-12-02 | 2003-12-02 | 10FF | 8d | 0d | Release Management | 8h |
| 12 | 1.1.2.8 | Milestone Approach |  | 1d | 2003-12-04 | 2003-12-04 | 11FF | 10d | 0d | Program Management | 8h |
| 13 | 1.1.2.9 | Budget and Resource Allocation |  | 1d | 2003-12-04 | 2003-12-04 | 12FF | 12d |  | Product Management | 8h |
| 14 | 1.1.3 | Project Organization |  | 1d | 2003-12-01 | 2003-12-01 | 5 | 0d |  | Program Management | 8h |
| 15 | 1.1.4 | Managerial Processes |  | 1d | 2003-12-02 | 2003-12-02 | 14 | 0d |  | Program Management | 8h |
| 16 | 1.1.5 | Project Structure |  | 1d | 2003-12-03 | 2003-12-03 | 15 | 0d |  | Program Management | 8h |
| 17 | 1.1.6 | Core Team organized | milestone | 1d | 2003-12-04 | 2003-12-04 | 16 | 0d |  |  |  |
| 18 | 1.1.7 | Business Opportunity |  | 1d | 2003-12-05 | 2003-12-05 | 17 | 0d |  | Product Management | 8h |
| 19 | 1.1.8 | Solution Concept |  | 1d | 2003-12-08 | 2003-12-08 | 18 | 0d |  | Program Management | 8h |
| 20 | 1.1.9 | Project Scope |  | 1d | 2003-12-09 | 2003-12-09 | 19 | 0d |  | Program Management | 8h |
| 21 | 1.1.10 | Solution Design Strategies |  | 1d | 2003-12-10 | 2003-12-10 | 20 | 0d |  | Program Management | 8h |
| 22 | 1.1.11 | Vision/Scope Document |  | 1d | 2003-12-11 | 2003-12-11 | 21 | 0d |  | Product Management | 8h |
| 23 | 1.1.12 | Vision/Scope Drafted | milestone | 1d | 2003-12-12 | 2003-12-12 | 22 | 0d |  |  |  |
| 24 | 1.1.13 | Identify Risks |  | 1d | 2003-12-15 | 2003-12-15 | 23 | 0d |  | Product Management; Program Management; Development; Test; User Experience | 40h |
| 25 | 1.1.14 | Analyze and Prioritize Risks |  | 1d | 2003-12-16 | 2003-12-16 | 24 | 0d |  | Product Management; Program Management; Development; Test; User Experience | 40h |
| 26 | 1.1.15 | Plan and Schedule Risks |  | 1d | 2003-12-17 | 2003-12-17 | 25 | 0d |  | Product Management; Program Management; Development; Test; User Experience | 40h |
| 27 | 1.1.16 | Risk Register |  | 1d | 2003-12-18 | 2003-12-18 | 26 | 0d |  | Product Management; Program Management; Development; Test; User Experience | 40h |
| 28 | 1.1.17 | Risk Assessment Drafted | milestone | 1d | 2003-12-19 | 2003-12-19 | 27 | 0d |  |  |  |
| 29 | 1.1.18 | Vision/Scope Approved | milestone | 1d | 2003-12-22 | 2003-12-22 | 28 | 0d |  |  |  |

Notes:
- 1: The master project schedule includes all of the detailed project schedules, including the release date. Like the master project plan, the master project schedule combines and integrates all the schedules from each team lead. The team determines the release date after negotiating the functional specification draft and reviewing the master project plan draft. Often, the team will modify some of the functional specification and/or master project plan to meet a required release date. Although features, resources, and release date may vary, a fixed release date will cause the team to prioritize features, assess risks, and plan adequately.
- 2: The envisioning phase addresses one of the most fundamental requirements for project successunification of the project team behind a common vision. The team must have a clear vision of what it wants to accomplish for the customer and be able to state it in terms that will motivate the entire team and the customer. Envisioning, by creating a high-level view of the projects goals and constraints, can serve as an early form of planning; it sets the stage for the more formal planning process that will take place during the projects planning phase.
- 3: Assign key team members to the project. Typically, the full team will not assembled yet. The initial team may often be playing multiple roles until all members are in place.
- 4: The Master Project Approach is the roll-up of all the project teams approaches. This includes an overall statement of strategy for the project and individual strategy statements for each team. A strategy statement describes a general approach to accomplish work without associated metrics. / The Master Project Approach also describes how the various project teams will collaborate to build and deploy the customer solution. This creates an awareness of the dependencies among the teams. / This section should also include a description of the high-level work tasks to be undertaken by each team. The work can be described in part by identifying what its result or deliverable will be. This description can also include things such as tools, methodologies, best practices, sequences of events, etc. / The Master Project Approach ensures that each team understands how it will contribute to the projects overall success. In addition, it communicates to the customer that Microsoft and its partners are working from a well-developed strategy. The Master Project Approach evolves into the Master Project Plan during the planning phase. / The sections below describe the project teams approach to building the project work packages. / Note: The sections identified below are suggested categories. Modify these categories to fit your project.
- 14: The Project Organization section defines how people will be organized in the project. The assurance of quality resources and structure begins with creating people "requirements" and follows with organizing those people into teams and allocating responsibility. Clear statements of skill requirements and roles and responsibilities enable the project manager to select the right people and communicate to them how they will contribute to the project's success.
- 15: Managerial Processes are the set of project processes that must be standardized to ensure all project participants are performing the processes in the same manner. This standardization creates performance efficiencies and facilitates a common language among the project stakeholders. / Describe management objectives, priorities, project assumptions, dependencies, constraints, risk management techniques, monitoring and controlling mechanisms, and the staffing plan.
- 16: The Project Structure document defines the approach the team will take in organizing and managing the project. It is the strategic representation of initial decisions made regarding goals, work scope, team requirements, team processes, and risk. / The project structure document also includes information on who plays which roles and has specific responsibilities. It clarifies the chain of accountability to the customer and designated points of contact that the project team has with the customer. These can vary depending on the circumstances of the project.
- 17: This is the point at which key team members have been assigned to the project. Typically, the full team is not assembled yet. The initial team may often be playing multiple roles until all members are in place.
- 18: The Business Opportunity section contains the statement of the customers situation. It is expressed in business language, not technical terms. This section should demonstrate the teams understanding of the customers current environment and its desired future state. This information is the overall context for the project.
- 19: A Solutions Concept provides a general description of the technical approach the project team will take to meet the customers needs. This includes an understanding of the users and their needs, the solutions features and functions, acceptance criteria, and the architectural and technical design approaches. / The Solution Concept provides teams with limited but sufficient detail to prove the solution to be complete and correct; to perform several types of analyses including feasibility studies, risk analysis, usability studies, and performance analysis; and to communicate the proposed solution to the customer and other key stakeholders.
- 20: The Scope places a boundary around the solution by detailing the range of features and functions, by defining what is out of scope, and by discussing the criteria by which the solution will be accepted by users and operations. The Scope clearly delineates what stakeholders expect the solution to do, thus making it a basis for defining project scope and for performing many types of project and operations planning.
- 21: The Solution Design Strategy describes the architectural and technical design approaches. / The Architectural Design Strategy describes how the features and functions will operate together to form the solution. It identifies the specific components of the solution and their relationships. A diagram illustrating these components and relationships is an excellent communication device. / The Technical Design Strategy documents the application of specific technologies to the Architectural Design. It is a high-level description of the key products and technologies to be used in developing the solution.
- 22: Th Vision/Scope phase represents the ideas and decisions developed during the envisioning phase. The goal of the phase, represented by the content of the Vision/Scope document, is to achieve team and customer agreement on the desired solution and overall project direction.
- 23: At this interim milestone, the first draft of the vision/scope document has been completed and is circulated among the team, customer, and stakeholders for review. During the review cycle, the document undergoes iterations of feedback, discussion, and change.
- 24: Risk Identification allows individuals to surface risks so that the team becomes aware of a potential problem. As the input to the risk management process, risk identification should be undertaken as early as possible and repeated frequently throughout the project life cycle.
- 25: Risk Analysis transforms the estimates or data about specific project risks that developed during risk identification into a form that the team can use to make decisions around prioritization. Risk Prioritization enables the team to commit project resources to manage the most important risks.
- 26: Risk Planning takes the information obtained from risk analysis and uses it to formulate strategies, plans, and actions. Risk Scheduling ensures that these plans are approved and then incorporated into the standard day-to-day project management process and infrastructure to ensure that risk management is carried out as part of the day-to-day activities of the team. Risk scheduling explicitly connects risk planning with project planning.
- 27: The Risk Register identifies which features are riskiest. The riskiest features should be sheduled for completion first. Problems requiring major changes to the architecture can be handled earlier in the project, thereby minimizing the impact to schedule and budget. / For more information on risk, see the MSF Risk Management Discipline whitepaper.
- 28: For more information on risk, see the MSF Risk Management Discipline whitepaper.
- 29: The vision/scope approved milestone culminates the envisioning phase. At this point, the project team and the customer have agreed on the overall direction for the project, as well as which features the solution will and will not include, and a general timetable for delivery.

| ID | WBS | Task | Type | Duration | Start | Finish | Predecessors | Total slack | Free slack | Resources | Work |
| --- | --- | --- | --- | --- | --- | --- | --- | --- | --- | --- | --- |
| 30 | 1.2 | **Planning** |  | 25d | 2003-12-23 | 2004-01-26 | 2 | 0d |  |  | 352h |
| 31 | 1.2.1 | Evaluate Technologies |  | 1d | 2003-12-23 | 2003-12-23 |  | 0d |  | Program Management | 8h |
| 32 | 1.2.2 | Baseline Customer Environment |  | 1d | 2003-12-24 | 2003-12-24 | 31 | 0d |  | Program Management | 8h |
| 33 | 1.2.3 | Technology Validation | milestone | 1d | 2003-12-25 | 2003-12-25 | 32 | 0d |  |  |  |
| 34 | 1.2.4 | Feature Cuts and Un-supported Scenarios |  | 1d | 2003-12-26 | 2003-12-26 | 33 | 0d |  | Program Management | 8h |
| 35 | 1.2.5 | Assumptions and Dependencies |  | 1d | 2003-12-29 | 2003-12-29 | 34 | 0d |  | Product Management; Program Management; Development; Test; User Experience; Release Management | 48h |
| 36 | 1.2.6 | Solution Design |  | 1d | 2003-12-30 | 2003-12-30 | 35 | 0d |  | Program Management | 8h |
| 37 | 1.2.7 | Security Strategy |  | 1d | 2003-12-31 | 2003-12-31 | 36 | 0d |  | Program Management; Development; Release Management | 24h |
| 38 | 1.2.8 | Installation/Setup Requirements |  | 1d | 2004-01-01 | 2004-01-01 | 37 | 0d |  | Release Management | 8h |
| 39 | 1.2.9 | Integration Requirements |  | 1d | 2004-01-02 | 2004-01-02 | 38 | 0d |  | Program Management; Development | 16h |
| 40 | 1.2.10 | Supportability Requirements |  | 1d | 2004-01-05 | 2004-01-05 | 39 | 0d |  | User Experience | 8h |
| 41 | 1.2.11 | Legal Requirements |  | 1d | 2004-01-06 | 2004-01-06 | 40 | 0d |  | Product Management | 8h |
| 42 | 1.2.12 | Functional Specification Baselined | milestone | 1d | 2004-01-07 | 2004-01-07 | 41 | 0d |  |  |  |
| 43 | 1.2.13 | Communication Plan |  | 1d | 2004-01-08 | 2004-01-08 | 42 | 5d |  | Product Management | 8h |
| 44 | 1.2.14 | Budget Plan |  | 1d | 2004-01-08 | 2004-01-08 | 42 | 1d | 0d | Program Management | 8h |
| 45 | 1.2.15 | Capacity Plan |  | 1d | 2004-01-09 | 2004-01-09 | 44 | 1d | 0d | Program Management | 8h |
| 46 | 1.2.16 | Monitoring Plan |  | 1d | 2004-01-12 | 2004-01-12 | 45 | 1d | 0d | Program Management | 8h |
| 47 | 1.2.17 | Pilot Plan |  | 1d | 2004-01-13 | 2004-01-13 | 46 | 1d | 0d | Program Management | 8h |
| 48 | 1.2.18 | Training Plan |  | 1d | 2004-01-14 | 2004-01-14 | 47 | 1d |  | Program Management | 8h |
| 49 | 1.2.19 | Development Plan |  | 1d | 2004-01-08 | 2004-01-08 | 42 | 4d | 0d | Development | 8h |
| 50 | 1.2.20 | Performance Plan |  | 1d | 2004-01-09 | 2004-01-09 | 49 | 4d | 0d | Development | 8h |
| 51 | 1.2.21 | Migration Plan |  | 1d | 2004-01-12 | 2004-01-12 | 50 | 9d | 0d | Development | 8h |
| 52 | 1.2.22 | Security Plan |  | 1d | 2004-01-13 | 2004-01-13 | 51 | 9d |  | Development | 8h |
| 53 | 1.2.23 | Test Plan |  | 1d | 2004-01-08 | 2004-01-08 | 42 | 5d |  | Test | 8h |
| 54 | 1.2.24 | User Support Plan |  | 1d | 2004-01-08 | 2004-01-08 | 42 | 5d |  | User Experience | 8h |
| 55 | 1.2.25 | Availability Plan |  | 1d | 2004-01-08 | 2004-01-08 | 42 | 0d |  | Release Management | 8h |
| 56 | 1.2.26 | Backup and Recovery Plan |  | 1d | 2004-01-09 | 2004-01-09 | 55 | 0d |  | Release Management | 8h |
| 57 | 1.2.27 | Deployment Plan |  | 1d | 2004-01-12 | 2004-01-12 | 56 | 0d |  | Release Management | 8h |
| 58 | 1.2.28 | Purchasing and Facilities Plan |  | 1d | 2004-01-13 | 2004-01-13 | 57 | 0d |  | Release Management | 8h |
| 59 | 1.2.29 | Support Plan |  | 1d | 2004-01-14 | 2004-01-14 | 58 | 0d |  | Release Management | 8h |
| 60 | 1.2.30 | Operations Plan |  | 1d | 2004-01-15 | 2004-01-15 | 59 | 0d |  | Release Management | 8h |
| 61 | 1.2.31 | Master Plan Baselined | milestone | 1d | 2004-01-16 | 2004-01-16 | 43, 54, 53, 60, 48, 50 | 0d |  |  |  |
| 62 | 1.2.32 | Define Master Schedule |  | 1d | 2004-01-19 | 2004-01-19 | 61 | 0d |  | Product Management; Program Management; Development; Test; User Experience; Release Management | 48h |
| 63 | 1.2.33 | Master Schedule Baselined | milestone | 1d | 2004-01-20 | 2004-01-20 | 62 | 0d |  |  |  |
| 64 | 1.2.34 | Set Up Development Environment |  | 1d | 2004-01-21 | 2004-01-21 | 63 | 0d |  | Release Management | 8h |
| 65 | 1.2.35 | Set Up Test Environment |  | 1d | 2004-01-22 | 2004-01-22 | 64 | 0d |  | Release Management | 8h |
| 66 | 1.2.36 | Development and Test Environment Set Up | milestone | 1d | 2004-01-23 | 2004-01-23 | 65 | 0d |  |  |  |
| 67 | 1.2.37 | Project Plans Approved | milestone | 1d | 2004-01-26 | 2004-01-26 | 66 | 0d |  |  |  |

Notes:
- 30: The planning phase is when the bulk of the planning for the project is completed. During this phase the team prepares the functional specification, works through the design process, and prepares work plans, cost estimates, and schedules for the various deliverables. / Early in the planning phase, the team analyzes and documents requirements in a list or tool. Requirements fall into four broad categories: business requirements, user requirements, operational requirements, and system requirements (those of the solution itself). As the team moves on to design the solution and create the functional specifications, it is important to maintain traceability between requirements and features. Traceability does not have to be on a one to one basis. Maintaining traceability serves as one way to check the correctness of design and to verify that the design meets the goals and requirements of the solution.
- 31: During technology validation, the team evaluates the products or technologies that will be used to build or deploy the solution to ensure that they work according to vendors specifications. This is the initial iteration of an effort that later produces a proof of concept and, ultimately, the development of the solution itself. / Often, technology validation involves competitive evaluations (sometimes called shoot outs) between rival technologies or suppliers.
- 32: Another activity that must be completed at this milestone is baselining the customer environment. The team conducts an audit (also known as discovery) of the as is production environment the solution will be operating in. This includes server configurations, network, desktop software, and all relevant hardware.
- 33: During technology validation, the team evaluates the products or technologies that will be used to build or deploy the solution to ensure that they work according to vendors specifications. This is the initial iteration of an effort that later produces a proof of concept and, ultimately, the development of the solution itself. / Often, technology validation involves competitive evaluations (sometimes called shoot outs) between rival technologies or suppliers. / Another activity that must be completed at this milestone is baselining the customer environment. The team conducts an audit (also known as discovery) of the as is production environment the solution will be operating in. This includes server configurations, network, desktop software, and all relevant hardware.
- 34: The Feature Cuts and Unsupported Scenarios section identifies the requirements that will not be met by this project or release. This should include the identification of any requirement (business, user, system, operational, usage scenario) that cannot be met and an explanation of why it cannot be met. This section may also identify future solution releases that will satisfy these requirements. / Just as it is important to provide detailed descriptions of what the project will deliver, it is equally important to describe features and scenarios that are being omitted from the project scope. This will further clarify the current project emphasis and deliverables and prevent possible misunderstanding or confusion.
- 35: The Assumptions and Dependencies section lists and defines the project-oriented assumptions and dependencies (as opposed to feature dependencies or environmental dependencies) that have been identified through the process of developing the Functional Specification. An example of a dependency is this: a delivery may require advanced skills in various product technologies or business processes. / List assumptions and dependencies separately. / Assumptions should be identified where actual data does not exist and will identify the actions required to verify those assumptions. Dependencies will identify any actions that must be taken to ensure those dependencies are incorporated into the project plans.
- 36: The Solution Design section identifies the design documents that have been developed and summarizes the overall solution design in a succinct statement. It should also define why each of these design documents is necessary for the project. / This information provides the reader with strategic context for the follow on reading. It explains the differences between the design documents and explains how each provides a unique picture of the solution.
- 37: The Security Strategy Summary section describes the solution security strategy that will influence the design. The following questions will assist in developing this strategy: / ·What are the principal objectives to providing a secure environment? / ·What compromises in security are necessary for user convenience, usability, and performance? / ·What specific security tools and technologies will be implemented within the solution? / The Physical Design document contains the specific security details in a per-feature/per-component format. This strategy section should be a brief synopsis of a uniform security strategy, along with references to the Security Plan.
- 38: The Installation/Setup Requirements Summary section is a summary of the environmental requirements for solution installation. This information may be derived from the Deployment Plans installation sections. The Physical Design document contains the detail on how these requirements will be satisfied.
- 39: The Integration Requirements Summary section is a summary of integration and interoperability requirements and the project goals related to these requirements. The Migration Plan may be referenced or summarized here, as it contains integration and interoperability specifications. The Physical Design document contains the detail on how integration will be delivered.
- 40: The Supportability Summary section is a summary of the supportability requirements and the project goals related to these requirements. The Operations Plan and Support Plan may be referenced or summarized here, as they contain supportability specifications. The Physical Design document contains the detail on how supportability will be delivered.
- 41: The Legal Requirements Summary section is a summary of any legal requirements to which the project must adhere. Legal requirements may come from the customers corporate policies or from regulatory agencies governing the customers industry.
- 42: At this milestone, the functional specification is complete enough for customer and stakeholder review. At this point the team baselines the specification and begins formally tracking changes. / The functional specification is the basis for building the master project plan and schedule. The functional specification is maintained as a detailed description, as viewed from the user perspective, of what the solution will look like and how it will behave. The functional specification can only be changed with customer approval. / The results of the design process are often documented in a design document that is separate from the functional specification. The design document is focused on describing the internal workings of the solution. The design document can be kept internal to the team and can be changed without burdening the customer with technical issues.
- 43: The Communication Plan describes how the project will establish a reliable means of assuring visibility and co-operation by communicating status and news about the project to all appropriate stakeholders.
- 44: The Budget defines the solutions estimated cost to the organization. It may provide information at multiple levels of detail for the overall solution and for each project or sub-project required to deliver the solution.
- 45: The Capacity Plan outlines the strategy for 1) assessing overall solution and component performance and 2) using this information to develop the plan for component acquisition, configuration, and upgrade.
- 46: The Monitoring Plan defines the process by which the operational environment will monitor the solution. It describes what will be monitored, what monitoring is looking for, how monitoring will be done, and how the results of monitoring will be reported and used.
- 47: The Pilot Plan describes what aspect of the solution will be delivered as a pilot and provides the details necessary to conduct the pilot successfully.
- 48: The Training Plan identifies the needs and processes for training the people who will participate in creating the solution.
- 49: This is the controlling document for managing a software project, and it defines the technical and managerial processes necessary to deliver the project requirements.
- 50: The Performance Plan describes the solutions performance requirements, what elements of the solution will be developed to measure performance, and how solution performance will be measured to ensure the requirements are continuously met.
- 51: The Migration Plan describes the migration from existing systems or applications to the new solution.
- 52: The Security Plan describes how the solution will be brought to acceptable security levels in order to operate successfully. This plan describes what security threats exist and how implementing security standards will mitigate those.
- 53: The Test Plan describes the strategy and approach used to plan, organize, and manage the projects testing activities. It identifies testing objectives, methodologies and tools, expected results, responsibilities, and resource requirements.
- 54: The End-user Support Plan guides how the end-users are supported in their use of the solution.
- 55: The Availability Plan describes the plans to ensure that the solution will be highly available. It addresses both the hardware and software sides of the solution.
- 56: The Backup and Recovery Plan presents the aspects of the solution relevant to backup and recovery, identifies and describes weaknesses in the system, and describes backup methods and recovery steps.
- 57: The Deployment Plan describes the factors necessary for a smooth deployment and transition to ongoing operations.
- 58: This document focuses on the physical hardware and facilities needed for the solution and the process for acquisition.
- 59: This document defines the technical and managerial processes necessary to support the software operationally.
- 60: The Operations Plan describes how day-to-day operations will occur when the solution is in place and provides guidance for the organization to maintain the solution successfully over an extended period of time.
- 61: In MSF, the master project plan is a collection (or roll up) of plans from the various roles. It is not an independent plan of its own. Depending on the type and size of project, there will be various types of plans that are merged into the master project plan. / The benefits of having a plan made up of smaller plans are that if facilitates concurrent planning by various team roles and provides for clear accountability because specific roles are responsible for specific plans. / The benefits of presenting these plans as one are that they facilitate synchronization into a single schedule, facilitate reviews and approvals, and help to identify gaps and inconsistencies.
- 62: The master project schedule includes all of the detailed project schedules, including the release date. Like the master project plan, the master project schedule combines and integrates all the schedules from each team lead. The team determines the release date after negotiating the functional specification draft and reviewing the master project plan draft. Often, the team will modify some of the functional specification and/or master project plan to meet a required release date. Although features, resources, and release date may vary, a fixed release date will cause the team to prioritize features, assess risks, and plan adequately.
- 63: The master project schedule includes all of the detailed project schedules, including the release date. Like the master project plan, the master project schedule combines and integrates all the schedules from each team lead. The team determines the release date after negotiating the functional specification draft and reviewing the master project plan draft. Often, the team will modify some of the functional specification and/or master project plan to meet a required release date. Although features, resources, and release date may vary, a fixed release date will cause the team to prioritize features, assess risks, and plan adequately.
- 64: A working development environment allows proper development of the solution. It is generally a good idea to set up separate development servers that developers can use. The entire team should be informed that anything on such servers could become unstable and require re-installation.
- 65: If the organization does not already have a suitable test lab in place, the team must build one. The test environment must be as close a simulation to the live environment as is feasible. While this can be expensive, it is very important. Otherwise, certain bugs may go undetected until the solution is deployed live to production. Organizations using MOF can take advantage of information contained in the enterprise Configuration Management Database (CMDB) as a kind of bill of materials for replicating the production environment.
- 66: In order to avoid delay, the development and testing environment should be set up even as plans are being finalized and reviewed. This includes development workstations, servers, and tools. The backup system should be established if it is not already in place. CD-ROM images of standard server configurations are often used as machines are often wiped or reformatted.
- 67: At the project plans approved milestone, the project team and key project stakeholders agree that interim milestones have been met, that due dates are realistic, that project roles and responsibilities are well defined, and that mechanisms are in place for addressing areas of project risk. The functional specifications, master project plan, and master project schedule provide the basis for making future trade-off decisions. / After the team approves the specifications, plans, and schedules, the documents become the project baseline. The baseline takes into account the various decisions that are reached by consensus by applying the three project planning variables: resources, schedule, and features. After the baseline is completed and approved, the team transitions to the developing phase. / After the team defines a baseline, it is placed under change control. This does not mean that all decisions reached in the planning phase are final. But it does mean that as work progresses in the developing phase, the team should review and approve any suggested changes to the baseline. / For organizations using MOF, the team submits a Request for Change (RFC) to IT operations at this milestone.

| ID | WBS | Task | Type | Duration | Start | Finish | Predecessors | Total slack | Free slack | Resources | Work |
| --- | --- | --- | --- | --- | --- | --- | --- | --- | --- | --- | --- |
| 68 | 1.3 | **Developing** |  | 4d | 2004-01-27 | 2004-01-30 | 30 | 0d |  |  |  |
| 69 | 1.3.1 | Proof of Concept Complete | milestone | 1d | 2004-01-27 | 2004-01-27 |  | 0d |  |  |  |
| 70 | 1.3.2 | Internal Build n Complete | milestone | 1d | 2004-01-28 | 2004-01-28 | 69 | 0d |  |  |  |
| 71 | 1.3.3 | Internal Build n+1 Complete | milestone | 1d | 2004-01-29 | 2004-01-29 | 70 | 0d |  |  |  |
| 72 | 1.3.4 | Scope Complete | milestone | 1d | 2004-01-30 | 2004-01-30 | 71 | 0d |  |  |  |
| 73 | 1.4 | **Stabilizing** |  | 14d | 2004-02-02 | 2004-02-19 | 68 | 0d |  |  |  |
| 74 | 1.4.1 | Bug Convergence | milestone | 1d | 2004-02-02 | 2004-02-02 |  | 0d |  |  |  |
| 75 | 1.4.2 | Zero Bug Bounce | milestone | 1d | 2004-02-03 | 2004-02-03 | 74 | 0d |  |  |  |
| 76 | 1.4.3 | Release Candidate n | milestone | 1d | 2004-02-04 | 2004-02-04 | 75 | 0d |  |  |  |
| 77 | 1.4.4 | Release Candidate n+1 | milestone | 1d | 2004-02-05 | 2004-02-05 | 76 | 0d |  |  |  |
| 78 | 1.4.5 | Evaluate Test Results Against Success Criteria |  | 1d | 2004-02-06 | 2004-02-06 | 77 | 0d |  |  |  |
| 79 | 1.4.6 | Complete Site Preparation Checklist and Procedures |  | 1d | 2004-02-09 | 2004-02-09 | 78 | 0d |  |  |  |
| 80 | 1.4.7 | Complete Implementation Procedures, Scripts, and Load Sets |  | 1d | 2004-02-10 | 2004-02-10 | 79 | 0d |  |  |  |
| 81 | 1.4.8 | Complete Training Material |  | 1d | 2004-02-11 | 2004-02-11 | 80 | 0d |  |  |  |
| 82 | 1.4.9 | Resolve Support Issues |  | 1d | 2004-02-12 | 2004-02-12 | 81 | 0d |  |  |  |
| 83 | 1.4.10 | Complete and Test the Rollback Plan |  | 1d | 2004-02-13 | 2004-02-13 | 82 | 0d |  |  |  |
| 84 | 1.4.11 | Pre-Production Test Complete | milestone | 1d | 2004-02-16 | 2004-02-16 | 83 | 0d |  |  |  |
| 85 | 1.4.12 | User Acceptance Testing Complete | milestone | 1d | 2004-02-17 | 2004-02-17 | 84 | 0d |  |  |  |
| 86 | 1.4.13 | Pilot Complete |  | 1d | 2004-02-18 | 2004-02-18 | 85 | 0d |  |  |  |
| 87 | 1.4.14 | Release Readiness | milestone | 1d | 2004-02-19 | 2004-02-19 | 86 | 0d |  |  |  |
| 88 | 1.5 | **Deploying** |  | 11d | 2004-02-20 | 2004-03-05 | 73 | 0d |  |  | 128h |
| 89 | 1.5.1 | Deploy Core Technology |  | 1d | 2004-02-20 | 2004-02-20 |  | 10d |  |  |  |
| 90 | 1.5.2 | Core Components Deployed | milestone | 1d | 2004-02-20 | 2004-02-20 |  | 0d |  |  |  |
| 91 | 1.5.3 | Deploy Site Components |  | 1d | 2004-02-23 | 2004-02-23 | 90 | 0d |  |  |  |
| 92 | 1.5.4 | Site Deployments Complete | milestone | 1d | 2004-02-24 | 2004-02-24 | 91 | 0d |  |  |  |
| 93 | 1.5.5 | Deployment Stable | milestone | 1d | 2004-02-25 | 2004-02-25 | 92 | 0d |  |  |  |
| 94 | 1.5.6 | Obtain Customer Feedback |  | 1d | 2004-02-26 | 2004-02-26 | 93 | 5d | 0d | Product Management | 8h |
| 95 | 1.5.7 | Obtain Customer Approval for Project |  | 1d | 2004-02-27 | 2004-02-27 | 94 | 5d |  | Product Management | 8h |
| 96 | 1.5.8 | Solution/Scope Comparison |  | 1d | 2004-02-26 | 2004-02-26 | 93 | 0d |  | Program Management | 8h |
| 97 | 1.5.9 | Stabilization Management |  | 1d | 2004-02-27 | 2004-02-27 | 96 | 0d |  | Program Management | 8h |
| 98 | 1.5.10 | Deployment Complete | milestone | 1d | 2004-03-01 | 2004-03-01 | 97 | 0d |  |  |  |
| 99 | 1.5.11 | Project Review |  | 1d | 2004-03-02 | 2004-03-02 | 98 | 0d |  | Product Management; Program Management; Development; Test; User Experience; Release Management | 48h |
| 100 | 1.5.12 | Customer Satisfaction Survey |  | 1d | 2004-03-03 | 2004-03-03 | 99 | 0d |  | Product Management; Program Management; Development; Test; User Experience; Release Management | 48h |
| 101 | 1.5.13 | Project Close-Out Report |  | 1d | 2004-03-04 | 2004-03-04 | 100 | 0d |  |  |  |
| 102 | 1.5.14 | Project Complete | milestone | 1d | 2004-03-05 | 2004-03-05 | 101 | 0d |  |  |  |

Notes:
- 68: During the developing phase the team accomplishes most of the building of solution components (documentation as well as code). However, some development work may continue into the stabilization phase in response to testing. / The developing phase involves more than code development and software developers. The infrastructure is also developed during this phase and all roles are active in building and testing deliverables.
- 69: The proof of concept tests key elements of the solution on a non-production simulation of the existing environment. The team walks operations staff and users through the solution to validate their requirements.
- 70: Because the developing phase focuses on building the solution, the project needs interim milestones that can help the team measure build progress. / Developing is done in parallel and in segments, so the team needs a way to measure progress as a whole. Internal builds accomplish this by forcing the team to synchronize pieces at a solution level. / How many builds and how often they occur will depend on the size and duration of the project. / Often it makes sense to set interim milestones to achieve a visual design freeze and a database freeze because of the many dependencies on these. For example, the screens that are needed to create documentation and the database schema form a deep part of the overall architecture.
- 71: Because the developing phase focuses on building the solution, the project needs interim milestones that can help the team measure build progress. / Developing is done in parallel and in segments, so the team needs a way to measure progress as a whole. Internal builds accomplish this by forcing the team to synchronize pieces at a solution level. / How many builds and how often they occur will depend on the size and duration of the project. / Often it makes sense to set interim milestones to achieve a visual design freeze and a database freeze because of the many dependencies on these. For example, the screens that are needed to create documentation and the database schema form a deep part of the overall architecture.
- 72: The developing phase culminates in the scope complete milestone. At this milestone, all features are complete and the solution is ready for external testing and stabilization. This milestone is the opportunity for customers and users, operations and support personnel, and key project stakeholders to evaluate the solution and identify any remaining issues that must be addressed before the solution is released.
- 73: The stabilizing phase conducts testing on a solution whose features are complete. Testing during this phase emphasizes usage and operation under realistic environmental conditions. The team focuses on resolving and triaging (prioritizing) bugs and preparing the solution for release. / Early during this phase it is common for testing to report bugs at a rate faster than developers can fix them. There is no way to tell how many bugs there will be or how long it will take to fix them. There are, however, a couple of statistical signposts known as bug convergence and zero-bug bounce that helps the team project when the solution will reach stability. These signposts are described below. / MSF avoids the terms alpha and beta to describe the state of IT projects. These terms are widely used, but are interpreted in too many ways to be meaningful in industry. Teams can use these terms if desired, as long as they are defined clearly and the definitions understood among the team, customer, and stakeholders. / Once a build has been deemed stable enough to be a release candidate, the solution is deployed to a pilot group. / The stabilizing phase culminates in the release readiness milestone. Once reviewed and approved, the solution is ready for full deployment to the live production environment.
- 74: Bug convergence is the point at which the team makes visible progress against the active bug count. That is, the rate of bugs resolved exceeds the rate of bugs found. Figure 10 illustrates bug convergence. / Because the bug rate will still go up and downeven after it starts its overall declinebug convergence usually manifests itself as a trend rather than a fixed point in time. After bug convergence, the number of bugs should continue to decrease until zero-bug release. Bug convergence tells the team that the end is actually within reach.
- 75: Zero-bug bounce is the point in the project when development finally catches up to testing and there are no active bugsfor the moment. Figure 11 illustrates a zero-bug bounce. After zero-bug bounce, the bug peaks should become noticeably smaller and should continue to decrease until the solution is stable enough for the team to build the first release candidate.
- 76: A series of release candidates are prepared and released to the pilot group. Each release candidate is an interim milestone. Other features of a release candidate are: / ·Each release candidate has all the elements it needs to be released to production. / ·Building a release candidate tests its fitness for release, that is, whether all necessary pieces are present. / ·The test period that follows generation of a release candidate determines whether a release candidate is ready to release to production or whether the team must generate a new release candidate with the appropriate fixes. / ·Testing release candidates, which is done internally by the team, requires highly focused and intensive efforts, and focuses heavily on flushing out showstopper bugs. / ·Testing requires a triage process for resolving any newly discovered bugs. / ·It is unlikely that the first release candidate will be the one that is released. Typically, show stopping bugs will be found during the intensive testing of a release candidate.
- 77: A series of release candidates are prepared and released to the pilot group. Each release candidate is an interim milestone. Other features of a release candidate are: / ·Each release candidate has all the elements it needs to be released to production. / ·Building a release candidate tests its fitness for release, that is, whether all necessary pieces are present. / ·The test period that follows generation of a release candidate determines whether a release candidate is ready to release to production or whether the team must generate a new release candidate with the appropriate fixes. / ·Testing release candidates, which is done internally by the team, requires highly focused and intensive efforts, and focuses heavily on flushing out showstopper bugs. / ·Testing requires a triage process for resolving any newly discovered bugs. / ·It is unlikely that the first release candidate will be the one that is released. Typically, show stopping bugs will be found during the intensive testing of a release candidate.
- 84: The focus of this interim milestone is to prepare for a pilot release. This interim milestone is important because the solution is about to touch the live production environment. For this reason the team must test as much of the entire solution as possible before the pilot test begins.
- 85: User acceptance testing and usability studies begin during the development phase and continue during stabilization. These are conducted to ensure that the new system is able to successfully meet user and business needs. This is not to be confused with customer acceptance, which occurs at the end of the project. / When this milestone has been achieved, users have tested and accepted the release in a non-production environment and verified that the system integrates with existing business applications and the IT production environment. The rollout and backout procedures should also be confirmed during this period.
- 86: During this interim milestone, the team will test as much of the entire solution in as true a production environment as possible. In MSF, a pilot release is a deployment to a subset of the live production environment or user group. Depending on the context of the project, a pilot release can take the following forms: / ·In an enterprise, a pilot can be a group of users or a set of servers in a data center. / ·In Web development, pilot release takes the form of hosting site files on staging server(s) or folders that are live on the Internet, only with a test Web address. / ·Commercial software vendors, such as Microsoft, often release products to a special group of early adopters prior to final release. / What all these forms of piloting have in common is that they are instances of testing under live conditions.
- 87: The release readiness milestone occurs at the point when the team has addressed all outstanding issues and has released the solution or placed it in service. At the release milestone, responsibility for ongoing management and support of the solution officially transfers from the project team to the operations and support teams.
- 90: Most infrastructure solutions include a number of components that provide the framework or backbone for the entire solution. These components do not represent the solution from the perspective of a specific set of users or a specific site. However, the deployment of sites or users generally depends on this framework. In addition: / Components are the enabling technology of the enterprise solution. Examples include domain controllers, mail routers, remote access servers, database servers. / Site deployments depend on this technology. / Depending on the solution, the core technology may need to be deployed before or in parallel with site deployments. / To avoid delays, core components may be reviewed and approved for deployment in advance of other parts of the solution still being stabilized. The operations staff must feel confident making this commitment before the whole solution has been proved to be stable.
- 92: At the completion of this milestone, all targeted users have access to the solution. Each site owner has signed off that their site is operating, though there may be some issues. / Customer and user feedback might reveal some problems. The training may not have gone well, or a part of the solution may have malfunctioned after the team departed the site. Some sites may need to be revisited based on feedback from site satisfaction surveys. / At this point, the team makes a concentrated effort to finish deployment activities and close out the project. / Many projects, notably in web development, do not involve client-side deployments and therefore this milestone is not applicable.
- 93: At the deployment stable interim milestone, the customer and team agree that the sites are operating satisfactorily. However, it is to be expected that some issues will arise with the various site deployments. These continue to be tracked and resolved. / It can be difficult to determine when a deployment is complete and the team can disengage. Newly deployed systems are often in a constant state of flux, with a continuous process of identifying and managing production support issues. The team can find it difficult to close out the project because of the ongoing issues that will surface after deployment. For this reason, the team will need to clearly define a completion milestone for the deployment rather than attempt to reach a point of absolute finality.
- 98: The deployment complete milestone culminates the deploying phase. By this time, the deployed solution should be providing the expected business value to the customer and the team should have effectively terminated the processes and activities it employed to reach this goal. / The customer must agree that the team has met its objectives before it can declare the solution to be in production and close out the project. This requires a stable solution, as well as clearly stated success criteria. In order for the solution to be considered stable, appropriate operations and support systems must be in place.
